# ServiceNow Upgrade Planning Checklist

Schedule from MS Project, 2019-02-07 to 2019-04-05.
7f29e9e4db272300e907595fdf96190b

## Calendars

- Standard: Mon-Fri 08:00-12:00, 13:00-17:00; Sat-Sun off.

## Schedule

| ID | WBS | Task | Duration | Start | Finish | Predecessors | Total slack | Free slack | Text10 |
| --- | --- | --- | --- | --- | --- | --- | --- | --- | --- |
| 1 | 1 | **Phase 1 - Read the release notes and plan your upgrade** | 4d | 2019-02-07 | 2019-02-12 |  | 0d |  | 6d9be968db272300e907595fdf96194f |
| 2 | 1.1 | Review upgrade best practices | 1d | 2019-02-07 | 2019-02-07 |  | -19d | 0d | e8895379dbafa300780ff35eae961957 |
| 3 | 1.2 | Review release notes | 3d | 2019-02-08 | 2019-02-12 | 2 | -19d | 0d | e59be968db272300e907595fdf961958 |
| 4 | 1.3 | Review the supported web browsers to determine browser prerequisites | 1d | 2019-02-07 | 2019-02-07 |  | 3d |  | 759be968db272300e907595fdf961998 |
| 5 | 2 | **Phase 2 - Prepare for the development instance upgrade** | 4d | 2019-02-13 | 2019-02-18 | 1 | 0d |  | 719be968db272300e907595fdf961961 |
| 6 | 2.1 | Confirm which ServiceNow instances are in-scope for upgrade. | 1d | 2019-02-13 | 2019-02-13 |  | 3d |  | b99be968db272300e907595fdf961969 |
| 7 | 2.2 | Confirm the instance hosting model | 1d | 2019-02-13 | 2019-02-13 |  | -19d | 0d | f19be968db272300e907595fdf961972 |
| 8 | 2.3 | Determine new functionality or notable changes that need to be validated after the upgrade. | 1d | 2019-02-13 | 2019-02-13 |  | -19d | 0d | 3d9be968db272300e907595fdf96197a |
| 9 | 2.4 | Confirm plans to enable or disable features introduced in the new product release. | 1d | 2019-02-13 | 2019-02-13 |  | 3d |  | 759be968db272300e907595fdf961983 |
| 10 | 2.5 | Create a project plan for cloning, upgrading, and testing. | 1d | 2019-02-14 | 2019-02-14 | 8, 7 | -19d | 0d | f19be968db272300e907595fdf9619c6 |
| 11 | 2.6 | Identify core team of testers, power users, and key stakeholders required to validate functionality in the ServiceNow instances before and after the upgrade. | 1d | 2019-02-13 | 2019-02-13 |  | 3d |  | 3d9be968db272300e907595fdf9619ce |
| 12 | 2.7 | Confirm any change freeze windows impacting the timing for environment clones or upgrades | 1d | 2019-02-13 | 2019-02-13 |  | 3d |  | 169b2d68db272300e907595fdf961928 |
| 13 | 2.8 | Confirm impact of non-production instance upgrade to development and testing | 1d | 2019-02-13 | 2019-02-13 |  | 3d |  | 8e9be968db272300e907595fdf9619df |
| 14 | 2.9 | Confirm the availability of other systems required for integration testing (key resources and environments). | 1d | 2019-02-13 | 2019-02-13 |  | 3d |  | c69be968db272300e907595fdf9619e8 |
| 15 | 2.10 | Confirm any restrictions in which ServiceNow instances can be used for integration testing | 1d | 2019-02-13 | 2019-02-13 |  | 3d |  | 029be968db272300e907595fdf9619f1 |
| 16 | 2.11 | Confirm the testing scope and approach | 1d | 2019-02-15 | 2019-02-15 | 10 | -19d | 0d | 4a9be968db272300e907595fdf9619f9 |
| 17 | 2.12 | Create a comprehensive test plan including test cases for all core instance functionality and integrations. | 1d | 2019-02-18 | 2019-02-18 | 16 | -19d | 0d | 4a9b2d68db272300e907595fdf96190e |
| 18 | 2.13 | Confirm the method for tracking any defects identified during testing. | 1d | 2019-02-13 | 2019-02-13 |  | 3d |  | 829b2d68db272300e907595fdf961917 |
| 19 | 2.14 | Create a high-level implementation plan | 1d | 2019-02-13 | 2019-02-13 |  | 2d | 0d | ca9b2d68db272300e907595fdf96191f |
| 20 | 2.15 | Confirm any change freeze windows impacting the timing for environment clones or upgrades | 1d | 2019-02-13 | 2019-02-13 |  | 3d |  | 469be968db272300e907595fdf9619d7 |
| 21 | 2.16 | Determine whether existing internal training materials, Knowledge Base articles in the customer instance, or other supporting documentation must be updated to a | 1d | 2019-02-14 | 2019-02-14 | 7, 8 | 2d |  | 5e9b2d68db272300e907595fdf961930 |
| 22 | 2.17 | Optional: Schedule the ServiceNow Configuration Review, which provides recommendations to align the customer configurations with ServiceNow best practices. | 1d | 2019-02-13 | 2019-02-13 |  | 3d |  | 969b2d68db272300e907595fdf961939 |
| 23 | 2.18 | Notify impacted users and internal stakeholders of the scheduled date/time for cloning (from production) and upgrade of the Sub-Production instance | 1d | 2019-02-13 | 2019-02-13 |  | 3d |  | 16ce35a6db6b2700c886f23aaf961919 |
| 24 | 2.19 | Create a system clone of your production instance and select your development instance as the Target instance | 1d | 2019-02-14 | 2019-02-14 | 19 | 2d |  | de9b2d68db272300e907595fdf961941 |

Notes:
- 1: Phase 1 -~Read the release notes and plan your upgrade / https://docs.servicenow.com/bundle/madrid-release-notes/page/release-notes/upgrades/task/upgrades-phase-1.html
- 2: Review the upgrade best practices available at https://www.servicenow.com/upgrades / The upgrade guide and best practices provides additional context and information that will help ensure a successful upgrade.
- 3: Review the~release notes~for the target ServiceNow feature release and patch as well as previous feature releases that may have been skipped. For example, if upgrading from Kingston to Madrid, be sure to read the London and Madrid release notes. / https://docs.servicenow.com/bundle/madrid-release-notes/page/release-notes/family-release-notes.html / https://docs.servicenow.com/bundle/london-release-notes/page/release-notes/family-release-notes.html / https://docs.servicenow.com/bundle/jakarta-release-notes/page/release-notes/family-release-notes.html / https://docs.servicenow.com/bundle/kingston-release-notes/page/release-notes/family-release-notes.html / Personalized release notes are provided as part of the Jumpstart your upgrade program. Release notes can also be found at https://docs.servicenow.com / For specific upgrade considerations, see~Upgrade and migration tasks by application or feature.
- 4: Review the~supported web browsers~to determine browser prerequisites. For example, versions and types supported, and additional requirements for new UI versions. Compare these supported browsers to your corporate standard and identify any gaps.
- 5: Phase 2 - Prepare for the development instance upgrade / https://docs.servicenow.com/bundle/madrid-release-notes/page/release-notes/upgrades/task/upgrades-phase-2.html
- 6: Confirm which ServiceNow instances are in-scope for upgrade.
- 7: Confirm the instance hosting model. For example, ServiceNow cloud, on-premise, or off-premise.
- 8: Based on the reviewed release notes~and other release materials, determine new functionality or notable changes that need to be validated after the upgrade.
- 9: Confirm plans to enable or disable features introduced in the new product release.
- 10: Create a project plan for cloning, upgrading, and testing.
- 11: Identify the core team of testers, power users, and key stakeholders required to validate functionality in the ServiceNow instances before and after the upgrade.
- 12: Confirm whether there are any change freeze windows impacting the timing for environment clones or upgrades. For example, end quarter.
- 13: Confirm which of the following situations applies to your ServiceNow non-production instances: / 1. Development and testing can be frozen until the production upgrade is completed. / 2. Continued development (and testing) activities need to continue in a non-production instance while upgrade, remediation, and testing activities are performed in parallel on another instance. / 3. Once the final upgrade to your production instance is complete, the cloning of your final production instance to your non-production instance will wait until~after~the production upgrade is complete.
- 14: Confirm the availability of other systems required for integration testing (key resources and environments).
- 15: Confirm whether there are any restrictions in which ServiceNow instances can be used for integration testing. For example, an interfacing system is only set up to access a specific ServiceNow test instance.
- 16: Confirm the testing scope and approach.
- 17: Create a comprehensive test plan including test cases for all core instance functionality and integrations.
- 18: Confirm the method for tracking any defects identified during testing.
- 19: Create a high-level implementation plan that covers: / - the sequence and timing to upgrade non-production and production instances / - the instances to be cloned / - the instance to be used for integration testing.
- 20: Confirm whether there are any change freeze windows impacting the timing for environment clones or upgrades. For example, end quarter.
- 21: Determine whether existing internal training materials, Knowledge Base articles in the customer instance, or other supporting documentation must be updated to align with the upgraded version. For example, changes in functionality or user interface.
- 22: Optional:~Schedule the~ServiceNow Configuration Review, which provides recommendations to align the customer configurations with ServiceNow best practices. / Note:~There may be a service charge and require professional services engagement.
- 23: Notify impacted users and internal stakeholders of the scheduled date/time for cloning (from production) and upgrade of the Sub-Production instance
- 24: On your production instance, create a system clone and select your development instance as the~Target instance.~Notify impacted users and internal stakeholders of the scheduled date/time for cloning (from production) and upgrade of the non-production instance. / Note:~It is important to test on a system that reflects the production instance as closely as possible. If your non-production and production instances are the same size, include the production audit log and the attachment data, and ensure that you have deselected the exclude options.

| ID | WBS | Task | Duration | Start | Finish | Predecessors | Total slack | Free slack | Text10 |
| --- | --- | --- | --- | --- | --- | --- | --- | --- | --- |
| 25 | 3 | **Phase 3 - Verify your upgrade configurations and schedule the development instance upgrade in HI** | 2d | 2019-02-19 | 2019-02-20 | 5 | 0d |  | 1a9b2d68db272300e907595fdf96194a |
| 26 | 3.1 | Check the configuration of the Upgrade scheduled job to view how often and when it runs | 1d | 2019-02-19 | 2019-02-19 |  | -19d | 0d | 1a9b2d68db272300e907595fdf96195f |
| 27 | 3.2 | Verify that the Upgrade sys_trigger is set properly for upgrading | 1d | 2019-02-19 | 2019-02-19 |  | -19d | 0d | 629b2d68db272300e907595fdf961968 |
| 28 | 3.3 | Verify that the Check Upgrade Script sys_trigger is set properly for upgrading | 1d | 2019-02-19 | 2019-02-19 |  | -19d | 0d | aa9b2d68db272300e907595fdf961970 |
| 29 | 3.4 | If applicable, request a version entitlement. | 1d | 2019-02-19 | 2019-02-19 |  | 1d |  | 2e9b2d68db272300e907595fdf961981 |
| 30 | 3.5 | Schedule the upgrade in HI | 1d | 2019-02-20 | 2019-02-20 | 28, 26, 27 | -19d | 0d | e29b2d68db272300e907595fdf961979 |
| 31 | 4 | **Phase 4 - Upgrade and validate the development instance** | 6d | 2019-02-21 | 2019-02-28 | 25 | 0d |  | 669b2d68db272300e907595fdf96198a |
| 32 | 4.1 | DEV: Using the Upgrade Monitor, monitor the upgrade; validate upgrade is complete. | 1d | 2019-02-21 | 2019-02-21 | 30, 17 | -19d | 0d | ae9b2d68db272300e907595fdf961992 |
| 33 | 4.2 | DEV: Process skipped records list in the Upgrade Monitor. | 3d | 2019-02-22 | 2019-02-26 | 32 | -19d | 0d | ae9b2d68db272300e907595fdf9619a7 |
| 34 | 4.3 | DEV: Identify update sets | 1d | 2019-02-21 | 2019-02-21 |  | 5d |  | e69b2d68db272300e907595fdf9619b0 |
| 35 | 4.4 | DEV: Before and after upgrading, conduct smoke tests | 2d | 2019-02-27 | 2019-02-28 | 33, 32 | -19d | 0d | 329b2d68db272300e907595fdf9619b9 |
| 36 | 5 | **Phase 5 - If applicable: Upgrade and validate your other non-production instances, such as your test instance** | 17d | 2019-03-01 | 2019-03-25 | 31 | 0d |  | 7a9b2d68db272300e907595fdf9619c1 |
| 37 | 5.1 | Notify impacted users and internal stakeholders of the scheduled date/time for cloning (from production) and upgrade of the Sub-Production instance | 1d | 2019-03-01 | 2019-03-01 |  | 16d |  | 4a6f7da6db6b2700c886f23aaf96192a |
| 38 | 5.2 | NON-PROD: Create a system clone from Prod and select the applicable NON-PROD instance as the Target instance | 1d | 2019-03-01 | 2019-03-01 |  | -19d | 0d | b29b2d68db272300e907595fdf9619ca |
| 39 | 5.3 | NON-PROD: Before upgrade, run Automated Tests | 1d | 2019-03-04 | 2019-03-04 | 38 | -20d | 0d | d1aded97dbbb6700c886f23aaf961979 |
| 40 | 5.4 | NON-PROD: Schedule upgrade in HI and verify upgrade configurations | 1d | 2019-03-05 | 2019-03-05 | 38, 39 | -20d | 0d | fa9b2d68db272300e907595fdf9619d2 |
| 41 | 5.5 | NON-PROD: Validate that the upgrade is complete. | 1d | 2019-03-06 | 2019-03-06 | 40 | -20d | 0d | 369b2d68db272300e907595fdf9619db |
| 42 | 5.6 | NON-PROD: Install any optional plugins that were installed on your development instance. | 1d | 2019-03-07 | 2019-03-07 | 41 | 0d |  | 369b2d68db272300e907595fdf9619f0 |
| 43 | 5.7 | NON-PROD: Install custom applications and post-upgrade fix scripts | 1d | 2019-03-08 | 2019-03-08 | 42 | 0d |  | 7e9b2d68db272300e907595fdf9619f8 |
| 44 | 5.8 | NON-PROD: Install update sets. | 1d | 2019-03-11 | 2019-03-11 | 43 | 0d |  | 879b6d68db272300e907595fdf961901 |
| 45 | 5.9 | NON-PROD: After upgrade, run Automated Tests | 1d | 2019-03-12 | 2019-03-12 | 41, 44 | 9d |  | 1daded97dbbb6700c886f23aaf96196e |
| 46 | 5.10 | NON-PROD: Perform functional testing and monitor the performance | 10d | 2019-03-12 | 2019-03-25 | 44 | 0d |  | cf9b6d68db272300e907595fdf961909 |
| 47 | 6 | **Phase 6 - Prepare to upgrade the production instance** | 4d | 2019-03-26 | 2019-03-29 | 36 | 0d |  | 0b9b6d68db272300e907595fdf961912 |
| 48 | 6.1 | Confirm non-production instance defects have been fixed and validated in update sets. | 1d | 2019-03-26 | 2019-03-26 | 46 | 0d |  | 0b9b6d68db272300e907595fdf961927 |
| 49 | 6.2 | Confirm the core team of key stakeholders to verify post-upgrade prod functionality | 1d | 2019-03-26 | 2019-03-26 | 17 | 3d |  | 0b9b6d68db272300e907595fdf96193c |
| 50 | 6.3 | Confirm coverage for Day 1 support post-upgrade. | 1d | 2019-03-26 | 2019-03-26 | 17 | 3d |  | 439b6d68db272300e907595fdf961945 |
| 51 | 6.4 | Create a Production Upgrade Implementation Plan | 1d | 2019-03-27 | 2019-03-27 | 48, 17 | 0d |  | 539b6d68db272300e907595fdf96195a |
| 52 | 6.5 | Schedule Implementation Plan walkthrough and sign-off | 1d | 2019-03-28 | 2019-03-28 | 51 | 0d |  | 9b9b6d68db272300e907595fdf961962 |
| 53 | 6.6 | Submit and obtain approvals for change records | 1d | 2019-03-28 | 2019-03-28 | 51 | 0d |  | d39b6d68db272300e907595fdf96196b |
| 54 | 6.7 | Send upgrade communications to key stakeholders and end users for production outage and new features | 1d | 2019-03-29 | 2019-03-29 | 53, 52 | 0d |  | 1f9b6d68db272300e907595fdf961973 |
| 55 | 6.8 | Profile the performance of your instance before upgrading | 1d | 2019-03-26 | 2019-03-26 |  | 3d |  | 579b6d68db272300e907595fdf96197c |
| 56 | 6.9 | Use the ServiceNow Performance homepage to document the performance of your instance before the upgrade | 1d | 2019-03-26 | 2019-03-26 |  | 3d |  | 9f9b6d68db272300e907595fdf961984 |
| 57 | 6.10 | On your clone, perform functional testing and monitor the performance of your instance. | 1d | 2019-03-28 | 2019-03-28 | 51 | 1d |  | d79b6d68db272300e907595fdf96198d |
| 58 | 6.11 | OPTIONAL: Conduct performance and load testing. | 1d | 2019-03-26 | 2019-03-26 |  | 3d |  | c041022adb6b2700c886f23aaf96198d |

Notes:
- 25: Phase 3 -~Verify your upgrade configurations and schedule the development instance upgrade in~HI / https://docs.servicenow.com/bundle/madrid-release-notes/page/release-notes/upgrades/task/upgrades-phase-3.html
- 26: Check the configuration of the~Upgrade~scheduled job to view how often and when it runs.
- 27: Verify that the~Upgrade~sys_trigger is set properly for upgrading.
- 28: Verify that the~Check Upgrade Script~sys_trigger is set properly for upgrading.
- 29: If applicable, request a version entitlement.
- 30: Schedule the upgrade in~HI.
- 31: Phase 4 -~Upgrade and validate the development instance / https://docs.servicenow.com/bundle/madrid-release-notes/page/release-notes/upgrades/task/upgrades-phase-3.html
- 32: Using the Upgrade Monitor, monitor the upgrade to your instance and validate that the upgrade to your development instance is complete.
- 33: After the upgrade for your development instance is complete,~process the skipped records list~in the Upgrade Monitor.
- 34: Identify your update sets.
- 35: Before and after upgrading, conduct smoke tests on your development instance. Use your comprehensive test plan to perform functional testing.
- 36: Phase 5 -~If applicable: Upgrade and validate your other non-production instances, such as your test instance / https://docs.servicenow.com/bundle/madrid-release-notes/page/release-notes/upgrades/task/upgrades-phase-5.html
- 37: Notify impacted users and internal stakeholders of the scheduled date/time for cloning (from production) and upgrade of the Sub-Production instance
- 38: On your production instance, create a system clone and select your development instance as the~Target instance.
- 39: Before executing the upgrade, Automated tests should be run to establish a baseline of what tests passed/failed prior to an upgrade. / Consider using and/or building tests using the Automated Testing Framework / https://docs.servicenow.com/bundle/madrid-application-development/page/administer/auto-test-framework/concept/atf-overview.html
- 40: Schedule the non-production upgrade in HI and verify your upgrade configurations.
- 41: Validate that the upgrade to your non-production instance is complete.
- 42: Install any optional plugins that were installed on your development instance.
- 43: Install any custom applications and post-upgrade fix scripts that you need.
- 44: Install update sets.
- 45: After executing the upgrade, Automated tests should be run again and compared against the pre-upgrade baseline to understand what impact the upgrade may have had on functionality.
- 46: Perform functional testing and monitor the performance of your instance.
- 47: Phase 6 -~Prepare to upgrade the production instance / https://docs.servicenow.com/bundle/madrid-release-notes/page/release-notes/upgrades/task/upgrades-phase-6.html
- 48: Confirm sign-off from IT and Business stakeholders that all non-production instance defects have been fixed and validated in update sets.
- 49: Confirm the core team of key stakeholders required to validate functionality in the ServiceNow instance after the production upgrade.
- 50: Confirm coverage for Day 1 support post-upgrade.
- 51: Create a Production Upgrade Implementation Plan that includes all upgrade steps, roles and responsibilities, communication plans, key contacts, support coverage for Day 1, and so forth.
- 52: Schedule a walkthrough and sign-off of the Implementation Plan with key stakeholders and the core team.
- 53: Submit and obtain approvals for change records as required by the organization change process.
- 54: Send a communication to key stakeholders and end users with details for the production upgrade outage, new features, and so forth.
- 55: Profile the performance of your instance before upgrading.
- 56: Use the~ServiceNow~Performance homepage to document the performance of your instance before the upgrade.
- 57: On your clone, perform functional testing and monitor the performance of your instance.
- 58: OPTIONAL: If there are concerns with system performance, it may beneficial to conduct performance and load testing, to determine any impact areas or remediation steps. (Recommended load testing products are Jmeter and LoadImpact)

| ID | WBS | Task | Duration | Start | Finish | Predecessors | Total slack | Text10 |
| --- | --- | --- | --- | --- | --- | --- | --- | --- |
| 59 | 7 | **Phase 7 - Upgrade the production instance** | 5d | 2019-04-01 | 2019-04-05 | 47 | 0d | 639b6d68db272300e907595fdf9619ed |
| 60 | 7.1 | PROD: Schedule the upgrade in HI | 1d | 2019-04-01 | 2019-04-01 | 57 | 0d | 639bad68db272300e907595fdf961902 |
| 61 | 7.2 | PROD: If applicable, request a version entitlement | 1d | 2019-04-01 | 2019-04-01 |  | 4d | ab9bad68db272300e907595fdf96190a |
| 62 | 7.3 | PROD: Monitor the upgrade and validate that the upgrade is complete | 1d | 2019-04-02 | 2019-04-02 | 60 | 0d | 639bad68db272300e907595fdf96192c |
| 63 | 7.4 | PROD: Apply update sets and post-upgrade fix scripts | 1d | 2019-04-03 | 2019-04-03 | 62 | 0d | 639bad68db272300e907595fdf961941 |
| 64 | 7.5 | PROD: User acceptance testing (UAT) | 1d | 2019-04-04 | 2019-04-04 | 63 | 0d | ab9bad68db272300e907595fdf961949 |
| 65 | 7.6 | Schedule a Lessons Learned meeting to discuss and document improvements to incorporate into the next ServiceNow upgrade cycle. | 1d | 2019-04-01 | 2019-04-01 |  | 4d | 1d51822adb6b2700c886f23aaf96196d |
| 66 | 7.7 | PROD: Celebrate | 1d | 2019-04-05 | 2019-04-05 | 64 | 0d | ab9bad68db272300e907595fdf96195e |

Notes:
- 59: Phase 7 -~Upgrade the production instance / https://docs.servicenow.com/bundle/madrid-release-notes/page/release-notes/upgrades/task/upgrades-phase-7.html
- 60: Schedule the upgrade in~HI.
- 61: If applicable, request a version entitlement.
- 62: Monitor the upgrade to your instance~and validate that the upgrade to your production instance is complete.
- 63: Apply any update sets and post-upgrade fix scripts that you have.
- 64: Validate and test your instance by conducting user acceptance testing (UAT).~Verify with all key stakeholders that the system is performing properly after production upgrade, and key functionality is available.
- 65: Schedule a Lessons Learned meeting to discuss and document improvements to incorporate into the next ServiceNow upgrade cycle.
- 66: Celebrate your new upgrade!
